# ProjectPlanASIC1.1detailed

Schedule from MS Project, 2008-05-01 to 2008-07-14, status date 2008-05-13, 7.5 hours a day, A marks actual dates.
CCLRC

## Calendars

- Standard: Mon-Fri 08:30-12:00, 13:00-17:00; Sat-Sun off. Exceptions (off unless hours are given): 2008-05-02, 2008-05-12 to 2008-05-13, 2008-06-25 to 2008-06-27, 2008-06-30.

## Resources

| Resource |
| --- |
| Jamie |
| Rebecca |
| Renato |

## Schedule

| ID | WBS | Task | Type | Duration | Start | Finish | Predecessors | Complete | Baseline start | Baseline finish | Baseline duration | Total slack | Free slack | Constraint | Resources | Work | Actual work |
| --- | --- | --- | --- | --- | --- | --- | --- | --- | --- | --- | --- | --- | --- | --- | --- | --- | --- |
| 1 | 1 | Preliminary design review | milestone | 3h | 2008-05-01 A | 2008-05-01 A |  | 100% | 2008-05-01 | 2008-05-01 | 3h |  |  |  |  |  |  |
| 2 | 2 | **Bug fix 3 (level-shift logic)** |  | 6.5d | 2008-05-01 A | 2008-05-14 A |  | 100% | 2008-05-01 | 2008-05-15 | 10d |  |  |  |  | 40.46h | 40.46h |
| 3 | 2.1 | Schematic design |  | 0.5d | 2008-05-01 A | 2008-05-01 A |  | 100% | 2008-05-01 | 2008-05-01 | 0.5d |  |  |  | Jamie | 3.75h | 3.75h |
| 4 | 2.2 | Simulation verification |  | 2d | 2008-05-01 A | 2008-05-06 A | 3 | 100% | 2008-05-01 | 2008-05-07 | 3d |  |  |  | Jamie | 15h | 15h |
| 5 | 2.3 | Layout of new circuits |  | 1d | 2008-05-07 A | 2008-05-07 A | 4 | 100% | 2008-05-07 | 2008-05-08 | 1d |  |  |  | Jamie | 7.5h | 7.5h |
| 6 | 2.4 | Insert into existing logic layout |  | 1d | 2008-05-08 A | 2008-05-08 A | 5 | 100% | 2008-05-08 | 2008-05-12 | 2d |  |  |  | Jamie | 7.5h | 7.5h |
| 7 | 2.5 | DRC full logic block |  | 0.5d | 2008-05-09 A | 2008-05-09 A | 6 | 100% | 2008-05-12 | 2008-05-13 | 1.5d |  |  |  | Jamie | 3.75h | 3.75h |
| 8 | 2.6 | LVS full logic block |  | 0.5d | 2008-05-14 A | 2008-05-14 A | 7 | 100% | 2008-05-14 | 2008-05-15 | 2d |  |  |  | Jamie | 2.96h | 2.96h |
| 9 | 3 | **Bug fix 1&2 (biases)** |  | 1d | 2008-05-27 | 2008-05-27 | 12 |  | 2008-05-16 | 2008-05-16 | 1d | 23.5d | 0d |  |  | 7.5h |  |
| 10 | 3.1 | Schematic & simulation |  | 3h | 2008-05-27 | 2008-05-27 |  |  | 2008-05-16 | 2008-05-16 | 3h | 23.5d | 0d |  | Jamie | 3h |  |
| 11 | 3.2 | Layout |  | 4.5h | 2008-05-27 | 2008-05-27 | 10 |  | 2008-05-16 | 2008-05-16 | 4.5h | 23.5d |  |  | Jamie | 4.5h |  |
| 12 | 4 | **Change preSample pixels to preShape** |  | 5d | 2008-05-20 A | 2008-05-26 A | 17 | 100% | 2008-05-19 | 2008-05-23 | 5d |  |  |  |  | 37.5h | 37.5h |
| 13 | 4.1 | Schematic changes |  | 1d | 2008-05-20 A | 2008-05-20 A |  | 100% | 2008-05-19 | 2008-05-19 | 1d |  |  |  | Jamie | 7.5h | 7.5h |
| 14 | 4.2 | Layout changes |  | 1d | 2008-05-21 A | 2008-05-21 A | 13 | 100% | 2008-05-20 | 2008-05-20 | 1d |  |  |  | Jamie | 7.5h | 7.5h |
| 15 | 4.3 | DRC |  | 1d | 2008-05-22 A | 2008-05-22 A | 14 | 100% | 2008-05-21 | 2008-05-21 | 1d |  |  |  | Jamie | 7.5h | 7.5h |
| 16 | 4.4 | LVS |  | 2d | 2008-05-23 A | 2008-05-26 A | 15 | 100% | 2008-05-22 | 2008-05-23 | 2d |  |  |  | Jamie | 15h | 15h |
| 17 | 5 | **Change test structures to preShape (v1)** |  | 4d | 2008-05-14 A | 2008-05-19 A | 2 | 100% | 2008-05-26 | 2008-06-02 | 6d |  |  |  |  | 30h | 30h |
| 18 | 5.1 | Schematics |  | 1d | 2008-05-14 A | 2008-05-14 A |  | 100% | 2008-05-26 | 2008-05-26 | 1d |  |  |  | Jamie | 7.5h | 7.5h |
| 19 | 5.2 | Layout |  | 2d | 2008-05-15 A | 2008-05-16 A | 18 | 100% | 2008-05-27 | 2008-05-28 | 2d |  |  |  | Jamie | 15h | 15h |
| 20 | 5.3 | LVS |  | 1d | 2008-05-19 A | 2008-05-19 A | 19 | 100% | 2008-05-29 | 2008-05-29 | 1d |  |  |  | Jamie | 7.5h | 7.5h |
| 21 | 6 | **Feasability study: Extra Trim bits** |  | 16d | 2008-05-19 A | 2008-06-09 A |  | 100% | 2008-05-08 | 2008-05-29 | 16d |  |  |  |  | 120h | 120h |
| 22 | 6.1 | Layout feasability |  | 2d | 2008-05-19 A | 2008-05-20 A |  | 100% | 2008-05-08 | 2008-05-09 | 2d |  |  | start no earlier than 2008-05-19 | Rebecca | 15h | 15h |
| 23 | 6.2 | Layout changes |  | 2w | 2008-05-21 A | 2008-06-03 A | 22 | 100% | 2008-05-12 | 2008-05-23 | 2w |  |  |  | Rebecca | 75h | 75h |
| 24 | 6.3 | DRC |  | 1d | 2008-06-04 A | 2008-06-04 A | 23 | 100% | 2008-05-26 | 2008-05-26 | 1d |  |  |  | Rebecca | 7.5h | 7.5h |
| 25 | 6.4 | LVS |  | 3d | 2008-06-05 A | 2008-06-09 A | 24 | 100% | 2008-05-27 | 2008-05-29 | 3d |  |  |  | Rebecca | 22.5h | 22.5h |

| ID | WBS | Task | Type | Duration | Start | Finish | Predecessors | Complete | Remaining | Baseline start | Baseline finish | Baseline duration | Total slack | Free slack | Constraint | Resources | Work | Actual work |
| --- | --- | --- | --- | --- | --- | --- | --- | --- | --- | --- | --- | --- | --- | --- | --- | --- | --- | --- |
| 26 | 7 | **Top Level Changes & Checks** |  | 12.5d | 2008-05-28 A | 2008-06-13 | 9 | 48% | 6.5d | 2008-06-03 | 2008-06-13 | 8.5d | 17.5d |  |  |  | 63.75h | 30h |
| 27 | 7.1 | Integrate new pixel layout |  | 2d | 2008-05-28 A | 2008-05-29 A |  | 100% |  | 2008-06-03 | 2008-06-04 | 2d |  |  |  | Jamie | 15h | 15h |
| 28 | 7.2 | Integrate new test pixels |  | 2d | 2008-05-30 | 2008-06-02 | 27 |  |  |  |  |  | 26d |  |  |  |  |  |
| 29 | 7.3 | Integrate new logic cells |  | 2d | 2008-06-03 A | 2008-06-04 A | 28 | 100% |  |  |  |  |  |  |  |  |  |  |
| 30 | 7.4 | DRC |  | 2d | 2008-06-05 A | 2008-06-06 | 29 | 25% | 1.5d | 2008-06-05 | 2008-06-06 | 2d | 19d | 0d |  | Jamie | 15h | 3.75h |
| 31 | 7.5 | LVS |  | 3d | 2008-06-09 A | 2008-06-11 | 30 | 50% | 1.5d | 2008-06-09 | 2008-06-11 | 3d | 17.5d | 0d |  | Jamie | 22.5h | 11.25h |
| 32 | 7.6 | Antennas |  | 0.5d | 2008-06-12 | 2008-06-12 | 31 |  |  | 2008-06-12 | 2008-06-12 | 0.5d | 17.5d | 0d |  | Jamie | 3.75h |  |
| 33 | 7.7 | Regenerate fill |  | 1d | 2008-06-12 | 2008-06-13 | 32 |  |  | 2008-06-12 | 2008-06-13 | 1d | 17.5d |  |  | Jamie | 7.5h |  |
| 34 | 8 | FDR | milestone | 6h | 2008-06-13 | 2008-06-13 |  |  |  | 2008-06-13 | 2008-06-13 | 6h | 2.2d | 0d | start no earlier than 2008-06-13 |  |  |  |
| 35 | 9 | **Contingency** |  | 15d | 2008-06-13 | 2008-07-10 | 34 |  |  | 2008-06-13 | 2008-07-10 | 3w | 2.2d |  |  |  |  |  |
| 36 | 9.1 | Update test pixels to new design (v1.1) |  | 2.5d | 2008-06-13 | 2008-06-18 |  |  |  |  |  |  | 2.2d | 0d |  |  |  |  |
| 37 | 9.2 | Final checks/changes |  | 2.5w | 2008-06-18 | 2008-07-10 | 36 |  |  |  |  |  | 2.2d |  |  |  |  |  |
| 38 | 10 | MPW Submission deadline | milestone | 1d | 2008-07-14 | 2008-07-14 | 36 |  |  | 2008-07-14 | 2008-07-14 | 1d | 0d |  | start no earlier than 2008-07-14 |  |  |  |
